# ÅVC

Schedule from MS Project, 2002-08-16 to 2008-04-18.
Sweco Bloco AB

## Calendars

- Standard: Mon-Fri 08:00-12:00, 13:00-17:00; Sat-Sun off.

## Schedule

| ID | WBS | Task | Type | Duration | Start | Finish | Baseline start | Baseline finish | Baseline duration | Total slack | Constraint |
| --- | --- | --- | --- | --- | --- | --- | --- | --- | --- | --- | --- |
| 1 | 1 | PRELIMINÄR TIDPLAN |  | 1d? | 2004-08-16 | 2004-08-16 |  |  |  | 959d |  |
| 3 | 2 | VÄSTERORT |  | 1d? | 2002-08-16 | 2002-08-16 | 2002-08-16 | 2002-08-16 | 1d? | 1480d | finish no earlier than 2002-08-16 |
| 5 | 3 | LUNDA | milestone | 0d? | 2002-08-16 | 2002-08-16 | 2002-08-16 | 2002-08-16 | 0d? | 1481d | start no earlier than 2002-08-16 |
| 6 | 4 | Markförhandlingar |  | 145d? | 2004-08-16 | 2005-03-04 | 2004-08-16 | 2005-03-04 | 145d? | 815d | start no earlier than 2004-08-16 |
| 7 | 5 | Tillstånd,bygglov |  | 160d? | 2005-02-28 | 2005-10-07 | 2005-02-28 | 2005-10-07 | 160d? | 660d | start no earlier than 2005-02-28 |
| 8 | 6 | Proj, upphandling |  | 175d? | 2005-08-08 | 2006-04-07 | 2005-08-08 | 2006-04-07 | 175d? | 530d | start no earlier than 2005-08-08 |
| 9 | 7 | Bygge |  | 180d? | 2006-04-10 | 2006-12-15 | 2006-04-10 | 2006-12-15 | 180d? | 350d | start no earlier than 2006-04-10 |
| 12 | 8 | LINTA,GJUTMÄSTAREN ELLER ANNAN | milestone | 0d? | 2002-08-16 | 2002-08-16 | 2002-08-16 | 2002-08-16 | 0d? | 1481d | start no earlier than 2002-08-16 |
| 13 | 9 | Markförhandlingar |  | 160d? | 2004-11-01 | 2005-06-10 | 2004-11-01 | 2005-06-10 | 160d? | 745d | start no earlier than 2004-11-01 |
| 14 | 10 | Tillstånd,bygglov |  | 255d? | 2005-06-06 | 2006-05-26 | 2005-06-06 | 2006-05-26 | 255d? | 495d | start no earlier than 2005-06-06 |
| 15 | 11 | Proj, upphandling |  | 180d? | 2006-06-12 | 2007-02-16 | 2006-06-12 | 2007-02-16 | 180d? | 305d | start no earlier than 2006-06-12 |
| 16 | 12 | Bygge |  | 195d? | 2007-02-26 | 2007-11-23 | 2007-02-26 | 2007-11-23 | 195d? | 105d | start no earlier than 2007-02-26 |
| 19 | 13 | SÖDERORT |  | 1d? | 2002-08-16 | 2002-08-16 | 2002-08-16 | 2002-08-16 | 1d? | 1480d | start no earlier than 2002-08-16 |
| 21 | 14 | SÄTRA - BREDÄNG |  | 1d? | 2002-08-16 | 2002-08-16 | 2002-08-16 | 2002-08-16 | 1d? | 1480d | finish no earlier than 2002-08-16 |
| 22 | 15 | Markförhandlingar |  | 160d? | 2004-11-01 | 2005-06-10 | 2004-11-01 | 2005-06-10 | 160d? | 745d | start no earlier than 2004-11-01 |
| 23 | 16 | Tillstånd,bygglov |  | 165d? | 2005-06-06 | 2006-01-20 | 2005-06-06 | 2006-01-20 | 165d? | 585d | start no earlier than 2005-06-06 |
| 24 | 17 | Proj, upphandling |  | 180d? | 2006-01-16 | 2006-09-22 | 2006-01-16 | 2006-09-22 | 180d? | 410d | start no earlier than 2006-01-16 |
| 25 | 18 | Bygge |  | 185d? | 2006-09-18 | 2007-06-01 | 2006-09-18 | 2007-06-01 | 185d? | 230d | start no earlier than 2006-09-18 |
| 28 | 19 | SKARPNÄCK ELLER ANNAN |  | 1d? | 2002-08-16 | 2002-08-16 | 2002-08-16 | 2002-08-16 | 1d? | 1480d | finish no earlier than 2002-08-16 |
| 29 | 20 | Markförhandlingar |  | 220d? | 2005-11-21 | 2006-09-22 | 2005-11-21 | 2006-09-22 | 220d? | 410d | start no earlier than 2005-11-21 |
| 30 | 21 | Tillstånd,bygglov |  | 130d? | 2006-09-18 | 2007-03-16 | 2006-09-18 | 2007-03-16 | 130d? | 285d | start no earlier than 2006-09-18 |
| 31 | 22 | Proj, upphandling |  | 110d? | 2007-03-26 | 2007-08-24 | 2007-03-26 | 2007-08-24 | 110d? | 170d | start no earlier than 2007-03-26 |
| 32 | 23 | Bygge |  | 165d? | 2007-09-03 | 2008-04-18 | 2007-09-03 | 2008-04-18 | 165d? | 0d | start no earlier than 2007-09-03 |
